Schedule from Planner, 2006-01-20 to 2006-05-22.

## Calendars

- Default: Mon-Sat 08:00-12:00, 13:00-17:00; Sun off. Exceptions (off unless hours are given): 2006-03-24 to 2006-03-25 08:00-12:00, 13:00-17:00, 2006-03-27 to 2006-04-01 08:00-12:00, 13:00-17:00.

## Resources

| Resource | Group | Notes |
| --- | --- | --- |
| Sarah Bailey | students | On vacation from 03/23 (evening) to 01/02 (evening). |
| Glenn LeBrasseur | students |  |
| Jacob Davidson | students |  |
| Andrew Greenberg |  |  |

## Schedule

| ID | WBS | Task | Type | Duration | Start | Finish | Predecessors | Constraint | Work |
| --- | --- | --- | --- | --- | --- | --- | --- | --- | --- |
| 1 | 1 | **Project Proposal Presentation** |  |  | 2006-01-20 | 2006-02-02 |  | must start on 2006-02-03 | 96h |
| 2 | 1.1 | Rough Draft ready for Andrew |  |  | 2006-01-20 | 2006-01-25 |  | start no earlier than 2006-01-20 | 40h |
| 3 | 1.2 | Rough Draft to Faust |  |  | 2006-01-26 | 2006-01-28 | 2 |  | 24h |
| 4 | 1.3 | work out schedule details w/ Andrew |  |  | 2006-01-25 | 2006-01-25 |  | must start on 2006-01-25 | 8h |
| 5 | 1.4 | project schedule |  |  | 2006-01-26 | 2006-01-26 | 4 |  | 8h |
| 6 | 1.5 | finalize written proposal |  |  | 2006-01-30 | 2006-01-31 | 5, 3, 2 |  | 16h |
| 7 | 1.6 | presentation slides/roles |  |  | 2006-01-30 | 2006-01-31 | 3 | start no earlier than 2006-01-27 | 16h |
| 8 | 1.7 | presentation dry run | milestone | 0d | 2006-02-01 | 2006-02-01 | 7, 6 | must start on 2006-02-01 |  |
| 9 | 1.8 | proposal presentation | milestone | 0d | 2006-02-03 | 2006-02-03 | 8 | must start on 2006-02-03 |  |
| 10 | 2 | **Choose Microcontroller** |  |  | 2006-02-03 | 2006-02-24 |  | start no earlier than 2006-02-04 | 152h |
| 11 | 2.1 | discussion |  |  | 2006-02-03 | 2006-02-08 | 1 |  | 40h |
| 12 | 2.2 | order microcontroller |  |  | 2006-02-09 | 2006-02-24 | 11 |  | 112h |
| 13 | 3 | block diagram upgrade |  |  | 2006-02-09 | 2006-02-15 | 11 | start no earlier than 2006-02-08 | 48h |
| 14 | 4 | **detailed schematic** |  |  | 2006-02-16 | 2006-03-03 | 11, 13 |  | 112h |
| 15 | 4.1 | power supply block |  |  | 2006-02-16 | 2006-03-03 |  |  | 112h |
| 16 | 4.2 | microcontroller block |  |  | 2006-02-16 | 2006-03-03 |  |  | 112h |
| 17 | 4.3 | interface block |  |  | 2006-02-16 | 2006-03-03 |  |  | 112h |
| 18 | 5 | Schematics design review + design interation |  |  | 2006-03-08 | 2006-03-10 | 14, 13, 10 | start no earlier than 2006-03-08 | 24h |
| 19 | 6 | **final layout** |  |  | 2006-03-11 | 2006-03-21 | 18 |  | 72h |
| 20 | 6.1 | Package list + check availability |  |  | 2006-03-11 | 2006-03-16 |  |  | 40h |
| 21 | 6.2 | board layout |  |  | 2006-03-11 | 2006-03-18 |  |  | 56h |
| 22 | 6.3 | produce and check Gerbers |  |  | 2006-03-20 | 2006-03-20 | 21 |  | 8h |
| 23 | 6.4 | validate |  |  | 2006-03-21 | 2006-03-21 | 22 |  | 8h |
| 24 | 7 | Board design done | milestone | 0d | 2006-03-21 | 2006-03-21 | 19 |  |  |
| 25 | 8 | Order components |  |  | 2006-03-22 | 2006-03-29 | 24 |  | 56h |
| 26 | 9 | FAB of board |  | 4d | 2006-03-30 | 2006-04-03 | 25, 24 |  | 24h |
| 27 | 10 | stuff board |  |  | 2006-04-04 | 2006-04-11 | 26 |  | 56h |
| 28 | 11 | Prototype constructed | milestone | 0d | 2006-04-11 | 2006-04-11 | 27 |  |  |

| ID | WBS | Task | Type | Duration | Start | Finish | Predecessors | Work |
| --- | --- | --- | --- | --- | --- | --- | --- | --- |
| 29 | 12 | **customize firmware** |  |  | 2006-03-22 | 2006-04-18 | 24 | 192h |
| 30 | 12.1 | queue scheme |  |  | 2006-03-22 | 2006-03-25 |  | 32h |
| 31 | 12.2 | interrupt handler |  |  | 2006-03-27 | 2006-04-06 | 30 | 80h |
| 32 | 12.3 | message handler |  |  | 2006-04-07 | 2006-04-14 | 31 | 56h |
| 33 | 12.4 | flash firmware |  |  | 2006-04-15 | 2006-04-18 | 32, 28 | 24h |
| 34 | 13 | Firmware demo (first LED blink over CAN) | milestone | 0d | 2006-04-18 | 2006-04-18 | 29, 28 |  |
| 35 | 14 | **Test prototype** |  |  | 2006-04-12 | 2006-04-13 | 28 | 16h |
| 36 | 14.1 | voltage tests |  |  | 2006-04-12 | 2006-04-12 | 28 | 4h |
| 37 | 14.2 | temperature tests? |  |  | 2006-04-12 | 2006-04-12 | 36 | 4h |
| 38 | 14.3 | power consumption test |  |  | 2006-04-13 | 2006-04-13 | 37 | 4h |
| 39 | 14.4 | noise test (RF) |  |  | 2006-04-13 | 2006-04-13 | 38 | 4h |
| 40 | 15 | **measure bus performance** |  |  | 2006-04-19 | 2006-04-27 | 35, 29 | 64h |
| 41 | 15.1 | single channel bus test |  |  | 2006-04-19 | 2006-04-22 |  | 32h |
| 42 | 15.2 | multiple (two?) channel bus test |  |  | 2006-04-24 | 2006-04-27 | 41 | 32h |
| 43 | 16 | white paper |  |  | 2006-04-28 | 2006-05-22 | 40, 24 | 168h |
